# Тема6

Schedule from MS Project, 2009-09-07 to 2009-11-12, costs in р..
ТИУиЭ

## Calendars

- Стандартный: Mon-Fri 09:00-13:00, 14:00-18:00; Sat-Sun off. Exceptions (off unless hours are given): 2009-11-04 (День согласия и примирения).

## Resources

| Resource | Unit | Rate |
| --- | --- | --- |
| Постановщик |  | 312.5 |
| Программист1 |  | 406.25 |
| Программист2 |  | 437.5 |
| Бумага | пачка | 200 |
| Междугородные переговоры |  |  |
| CD-матрица | штука | 10 |
| Инженер по жокументации |  | 312.5 |

## Schedule

| ID | WBS | Task | Type | Duration | Start | Finish | Predecessors | Total slack | Free slack | Constraint | Deadline | Resources | Work | Cost |
| --- | --- | --- | --- | --- | --- | --- | --- | --- | --- | --- | --- | --- | --- | --- |
| 1 | 1 | Начало реализации проекта | milestone | 0d | 2009-09-07 | 2009-09-07 |  | -2d | 0d |  |  |  |  |  |
| 2 | 2 | **Программирование** |  | 27d | 2009-09-07 | 2009-10-13 |  | -4d | 0d |  |  |  | 288h | 116,730 |
| 3 | 2.1 | Постановка задачи |  | 10d | 2009-09-07 | 2009-09-22 | 1 | -2d | 0d |  |  | Постановщик; Бумага [1 пачка]; CD-матрица [0.03 штука]; Междугородные переговоры [0.2%] | 80h | 26,220 |
| 4 | 2.2 | Разработка интерфейса |  | 5d | 2009-09-23 | 2009-09-29 | 3 | 0d |  |  |  | Программист1; CD-матрица [0.12 штука]; Междугородные переговоры [0.1%] | 40h | 16,800 |
| 5 | 2.3 | Разработка модулей обработки данных |  | 6d | 2009-10-02 | 2009-10-09 | 4, 6 | -2d | 0d |  |  | Программист1; CD-матрица [0.12 штука] | 48h | 19,560 |
| 6 | 2.4 | Разработка структуры базы данных |  | 7d | 2009-09-23 | 2009-10-01 | 3 | -4d | 0d |  |  | Программист2; CD-матрица [0.12 штука]; Междугородные переговоры [0.3%] | 56h | 26,070 |
| 7 | 2.5 | Заполнение базы данных |  | 8d | 2009-10-02 | 2009-10-13 | 6 | -4d | 0d |  |  | Программист2; CD-матрица [0.12 штука] | 64h | 28,080 |
| 8 | 2.6 | Программирование завершено | milestone | 0d | 2009-10-13 | 2009-10-13 | 5, 7 | -1d | 0d |  |  |  |  |  |
| 9 | 3 | **Отладка** |  | 21d | 2009-10-14 | 2009-11-12 |  | -4d | 0d |  |  |  | 400h | 160,350 |
| 10 | 3.1 | Отладка программного комплекса |  | 8d | 2009-10-14 | 2009-10-26 | 8 | -4d | 0d |  |  | Постановщик; Программист1; Программист2; CD-матрица [0.25 штука] | 120h | 46,350 |
| 11 | 3.2 | Тестирование и исправление ошибок |  | 12d | 2009-10-27 | 2009-11-12 | 10 | -4d | 0d | finish no later than 2009-11-16 | 2009-11-09 | Постановщик; Программист1; Программист2; CD-матрица [0.25 штука] | 240h | 95,200 |
| 12 | 3.3 | Составление программной документации |  | 2d | 2009-10-27 | 2009-11-12 | 10 | 0d |  | as late as possible |  | Постановщик [50%]; CD-матрица [10 штука]; Междугородные переговоры [0.5%]; Программист1; Программист2 | 40h | 18,800 |
| 13 | 3.4 | Отладка завершена | milestone | 0d | 2009-11-12 | 2009-11-12 | 11, 12 | 0d |  |  |  |  |  |  |
| 14 | 4 | Конец проекта | milestone | 0d | 2009-11-12 | 2009-11-12 | 13 | 0d |  |  |  |  |  |  |
